# ComptonPET

Schedule from MS Project, 2005-08-01 to 2010-07-30, A marks actual dates.
um

## Calendars

- Standard: Mon-Fri 08:00-12:00, 13:00-17:00; Sat-Sun off.

## Schedule

| ID | WBS | Task | Duration | Start | Finish | Predecessors | Complete | Remaining | Total slack | Free slack | Constraint |
| --- | --- | --- | --- | --- | --- | --- | --- | --- | --- | --- | --- |
| 1 | 1 | **Phase I Demonstration** | 893d? | 2005-08-01 A | 2008-12-31 |  |  | 892.79d? | 412d |  |  |
| 2 | 1.1 | Development of more complete benchtop system | 132d? | 2005-08-01 | 2006-01-31 |  |  |  | 1173d |  | start no earlier than 2005-08-01 |
| 3 | 1.2 | Demonstrate energy discrimination capability | 152d? | 2005-08-01 | 2006-02-28 |  |  |  | 1153d |  | start no earlier than 2005-08-01 |
| 4 | 1.3 | **Outer detector "ring"** | 239d? | 2005-08-01 A | 2006-06-29 |  |  | 238.42d? | 1066d |  |  |
| 5 | 1.3.1 | Interface BGO detectors --> ADCs | 23d? | 2005-08-01 | 2005-08-31 |  |  |  | 1132d | 0d | start no earlier than 2005-08-01 |
| 6 | 1.3.2 | Calibrate BGO modules | 86d? | 2005-09-01 A | 2005-12-29 | 5 | 1% | 85d? | 1131d | 0d | start no earlier than 2005-03-01 |
| 7 | 1.3.3 | Incorporate into test bench | 65d? | 2005-12-30 | 2006-03-30 | 6 |  |  | 1131d |  |  |
| 8 | 1.3.4 | Write data acquisition and calibration software | 239d? | 2005-08-01 | 2006-06-29 |  |  |  | 1066d |  | start no earlier than 2005-08-01 |
| 9 | 1.4 | Develop Monte Carlo Simulation of platform geometry -- compare prediction and experiment | 370d? | 2005-08-01 | 2006-12-29 |  |  |  | 935d |  | start no earlier than 2005-08-01 |
| 10 | 1.5 | Conduct theoretical and experimental timing studies | 543d? | 2005-12-01 | 2007-12-31 |  |  |  | 674d |  | start no earlier than 2005-12-01 |
| 11 | 1.6 | Implementation and Evaluation of data processing methods | 654d? | 2005-08-01 | 2008-01-31 |  |  |  | 651d |  | start no earlier than 2005-08-01 |
| 12 | 1.7 | Image reconstruction | 500d? | 2006-07-03 | 2008-05-30 |  |  |  | 565d |  | start no earlier than 2006-07-01 |
| 13 | 1.8 | Compton kinematics for randoms and scatter rejection | 543d? | 2006-06-01 | 2008-06-30 |  |  |  | 544d |  | start no earlier than 2006-06-01 |
| 14 | 1.9 | Assess value of multiresolution information | 893d? | 2005-08-01 | 2008-12-31 |  |  |  | 412d |  | start no earlier than 2005-08-01 |
| 15 | 2 | Specific Experiments for demonstrator??? | 1d? | 2005-08-01 | 2005-08-01 |  |  |  | 1304d |  | start no earlier than 2005-08-01 |
| 17 | 3 | **Development tasks for Compton PET scale up (Phase II)** | 1305d? | 2005-08-01 | 2010-07-30 |  |  |  | 0d |  |  |
| 18 | 3.1 | **Refine detector and electronics requirements** | 631d? | 2005-08-01 | 2007-12-31 |  |  |  | 674d |  |  |
| 19 | 3.1.1 | Optimum pad size and thickness | 261d? | 2005-08-01 | 2006-07-31 |  |  |  | 1044d |  | start no earlier than 2005-08-01 |
| 20 | 3.1.2 | Noise requirements | 631d? | 2005-08-01 | 2007-12-31 |  |  |  | 674d |  | start no earlier than 2005-08-01 |
| 21 | 3.1.3 | Countrate requirements | 370d? | 2005-08-01 | 2006-12-29 |  |  |  | 935d |  | start no earlier than 2005-08-01 |
| 22 | 3.1.4 | Timing requirements | 370d? | 2005-08-01 | 2006-12-29 |  |  |  | 935d |  | start no earlier than 2005-08-01 |
| 23 | 3.2 | **Data acquisition requirements** | 698d? | 2006-05-01 | 2008-12-31 |  |  |  | 412d |  |  |
| 24 | 3.2.1 | Event rate requirements | 698d? | 2006-05-01 | 2008-12-31 |  |  |  | 412d |  | start no earlier than 2006-05-01 |
| 25 | 3.2.2 | Preprocessing requirements | 698d? | 2006-05-01 | 2008-12-31 |  |  |  | 412d |  | start no earlier than 2006-05-01 |

| ID | WBS | Task | Duration | Start | Finish | Total slack | Constraint |
| --- | --- | --- | --- | --- | --- | --- | --- |
| 26 | 3.3 | **Detector investigations** | 742d? | 2005-08-01 | 2008-06-03 | 563d |  |
| 27 | 3.3.1 | Examine feasibility of DSSDs | 218d? | 2005-08-01 | 2006-05-31 | 1087d | start no earlier than 2005-08-01 |
| 28 | 3.3.2 | Evaluate detector technologies for achieving element sizes of 0.3 - 0.8mm | 393d? | 2006-12-01 | 2008-06-03 | 563d | start no earlier than 2006-12-01 |
| 29 | 3.3.3 | Examine use of capacitively coupled pad readout | 566d? | 2005-12-01 | 2008-01-31 | 651d | start no earlier than 2005-12-01 |
| 30 | 3.3.4 | Investigate methods for minimizing inactive area | 566d? | 2005-12-01 | 2008-01-31 | 651d | start no earlier than 2005-12-01 |
| 31 | 3.4 | **Packaging technologies -connecting the detectors to ASICs to readout system** | 696d? | 2005-08-01 | 2008-03-31 | 609d |  |
| 32 | 3.4.1 | TAB bonding | 675d? | 2005-08-01 | 2008-02-29 | 630d | start no earlier than 2005-08-01 |
| 33 | 3.4.2 | Wire-bonding | 696d? | 2005-08-01 | 2008-03-31 | 609d | start no earlier than 2005-08-01 |
| 34 | 3.4.3 | Peltier cooling | 696d? | 2005-08-01 | 2008-03-31 | 609d | start no earlier than 2005-08-01 |
| 35 | 3.5 | Next generation ASICs | 284d? | 2006-06-01 | 2007-07-03 | 803d | start no earlier than 2006-06-01 |
| 36 | 3.6 | Further development of data processing technologies | 956d? | 2006-12-01 | 2010-07-30 | 0d | start no earlier than 2006-12-01 |
| 37 | 3.7 | Design and test readout electronics for Phase II demonstrator | 391d? | 2008-01-01 | 2009-06-30 | 283d | start no earlier than 2008-01-01 |
| 39 | 4 | **Phase II Demonstrator construction and testing** | 1305d? | 2005-08-01 | 2010-07-30 | 0d |  |
| 40 | 4.1 | Develop two densely-packed silicon detector stacks | 760d? | 2007-09-03 | 2010-07-30 | 0d | start no earlier than 2007-09-01 |
| 41 | 4.2 | Scale up readout and coincidence electronics | 455d? | 2007-09-03 | 2009-05-29 | 305d | start no earlier than 2007-09-01 |
| 42 | 4.3 | Implement 3D multi-resolution reconstrution software | 695d? | 2007-12-03 | 2010-07-30 | 0d | start no earlier than 2007-12-01 |
| 43 | 4.4 | Incoroporate various candidate geometries into Monte Carlo modeling code | 695d? | 2007-12-03 | 2010-07-30 | 0d | start no earlier than 2007-12-01 |
| 44 | 4.5 | **Experiments** | 1d? | 2005-08-01 | 2005-08-01 | 1304d |  |
| 45 | 4.5.1 | **Performance characterization and comparison with predictions** | 1d? | 2005-08-01 | 2005-08-01 | 1304d |  |
| 46 | 4.5.1.1 | Characterization of resolution | 1d? | 2005-08-01 | 2005-08-01 | 1304d | start no earlier than 2005-08-01 |
| 47 | 4.5.1.2 | Scatter | 1d? | 2005-08-01 | 2005-08-01 | 1304d | start no earlier than 2005-08-01 |
| 48 | 4.5.1.3 | NECR | 1d? | 2005-08-01 | 2005-08-01 | 1304d | start no earlier than 2005-08-01 |
| 49 | 4.5.2 | Performance extrapolation to full ring device | 1d? | 2005-08-01 | 2005-08-01 | 1304d | start no earlier than 2005-08-01 |
| 51 | 5 | Fabrication of Detectors for Development Phase | 370d? | 2005-08-01 | 2006-12-29 | 935d | start no earlier than 2005-08-01 |
| 52 | 6 | Fabrication of new ASICs | 347d? | 2006-09-01 | 2007-12-31 | 674d | start no earlier than 2006-09-01 |
| 53 | 7 | Fabrication of Phase II Detectors | 347d? | 2007-09-03 | 2008-12-30 | 413d | start no earlier than 2007-09-01 |
